# MIJLPALEN SCHEMA kantoorgebouw

Schedule from MS Project, 2004-05-31 to 2005-07-22.
BAM Nelissen Van Egteren

## Calendars

- Standaard: Mon-Fri 08:30-12:30, 13:00-17:00; Sat-Sun off.

## Schedule

| ID | WBS | Task | Type | Duration | Start | Finish | Total slack | Constraint |
| --- | --- | --- | --- | --- | --- | --- | --- | --- |
| 1 | 1 | **AANLOOP FASE** |  | 15d | 2004-05-31 | 2004-06-21 | 284d |  |
| 2 | 1.1 | start bouwproces | milestone | 0w | 2004-05-31 | 2004-05-31 | 299d |  |
| 3 | 1.2 | 1e paal heien | milestone | 0w | 2004-06-14 | 2004-06-14 | 289d | start no earlier than 2004-06-14 |
| 4 | 1.3 | palen geheid | milestone | 0w | 2004-06-21 | 2004-06-21 | 284d | start no earlier than 2004-06-21 |
| 5 | 2 | **ONDERBOUW FASE** |  | 8d | 2004-07-07 | 2004-07-16 | 264d |  |
| 6 | 2.1 | funderingsbalken gestort | milestone | 0w | 2004-07-07 | 2004-07-07 | 272d | start no earlier than 2004-07-07 |
| 7 | 2.2 | beg.grond vloer gestort | milestone | 0w | 2004-07-16 | 2004-07-16 | 264d | finish no earlier than 2004-07-16 |
| 8 | 3 | **BOVENBOUWFASE** |  | 80d | 2004-08-25 | 2004-12-15 | 157d |  |
| 9 | 3.1 | skelet vloerveld 1 L gestort | milestone | 0w | 2004-08-25 | 2004-08-25 | 237d | start no earlier than 2004-08-25 |
| 10 | 3.2 | skelet vloer 1 gestort | milestone | 0w | 2004-09-09 | 2004-09-09 | 225d | finish no earlier than 2004-09-09 |
| 11 | 3.3 | skelet vloer 2 gesort | milestone | 0w | 2004-10-01 | 2004-10-01 | 209d | finish no earlier than 2004-10-01 |
| 12 | 3.4 | skelet vloer 3 gestort | milestone | 0w | 2004-10-26 | 2004-10-26 | 192d | finish no earlier than 2004-10-26 |
| 13 | 3.5 | sklet vloer 4 gestort | milestone | 0w | 2004-11-19 | 2004-11-19 | 175d | start no earlier than 2004-11-19 |
| 14 | 3.6 | dakvloer gestort | milestone | 0w | 2004-12-15 | 2004-12-15 | 157d | start no earlier than 2004-12-15 |
| 15 | 4 | **GEVEL/DAK FASE** |  | 53d | 2005-01-18 | 2005-04-01 | 80d |  |
| 16 | 4.1 | dakopbouw beplaat | milestone | 0w | 2005-01-18 | 2005-01-18 | 133d | start no earlier than 2005-01-18 |
| 17 | 4.2 | dakafwerking waterdicht | milestone | 0w | 2005-02-18 | 2005-02-18 | 110d | start no earlier than 2005-02-18 |
| 18 | 4.3 | linkervleugel laatste steen | milestone | 0w | 2005-02-09 | 2005-02-09 | 117d | start no earlier than 2005-02-09 |
| 19 | 4.4 | linkervleugel waterdicht | milestone | 0w | 2005-02-22 | 2005-02-22 | 108d | start no earlier than 2005-02-22 |
| 20 | 4.5 | rechtervleugel laatste steen | milestone | 0w | 2005-03-18 | 2005-03-18 | 90d | start no earlier than 2005-03-18 |
| 21 | 4.6 | rechtervleugel waterdicht | milestone | 0w | 2005-04-01 | 2005-04-01 | 80d | start no earlier than 2005-04-01 |
| 22 | 5 | **AFBOUW LINKERVLEUGEL** |  | 51d | 2005-03-16 | 2005-05-26 | 41d |  |
| 23 | 5.1 | **inbouwfase** |  | 25d | 2005-03-16 | 2005-04-20 | 67d |  |
| 24 | 5.1.1 | dekvloer 4 L gelegd | milestone | 0w | 2005-03-16 | 2005-03-16 | 92d | start no earlier than 2005-03-16 |
| 25 | 5.1.2 | dekvloer 2 L gelegd | milestone | 0w | 2005-03-30 | 2005-03-30 | 82d | start no earlier than 2005-03-30 |
| 26 | 5.1.3 | dekvloer BG L gelegd | milestone | 0w | 2005-04-13 | 2005-04-13 | 72d | start no earlier than 2005-04-13 |
| 27 | 5.1.4 | wanden 3 L gesloten | milestone | 0w | 2005-04-06 | 2005-04-06 | 77d | start no earlier than 2005-04-06 |
| 28 | 5.1.5 | wanden 1 L gesloten | milestone | 0w | 2005-04-20 | 2005-04-20 | 67d | start no earlier than 2005-04-20 |

| ID | WBS | Task | Type | Duration | Start | Finish | Total slack | Constraint |
| --- | --- | --- | --- | --- | --- | --- | --- | --- |
| 29 | 5.2 | **afwerkingsfase** |  | 31d | 2005-04-13 | 2005-05-26 | 41d |  |
| 30 | 5.2.1 | plafond 4 L gesloten | milestone | 0w | 2005-04-13 | 2005-04-13 | 72d | start no earlier than 2005-04-13 |
| 31 | 5.2.2 | plafond 2 L gesloten | milestone | 0w | 2005-04-27 | 2005-04-27 | 62d | start no earlier than 2005-04-27 |
| 32 | 5.2.3 | plafond BG L gesloten | milestone | 0w | 2005-05-13 | 2005-05-13 | 50d | start no earlier than 2005-05-13 |
| 33 | 5.2.4 | vloerbedekking 3 L gelegd | milestone | 0w | 2005-05-12 | 2005-05-12 | 51d | start no earlier than 2005-05-12 |
| 34 | 5.2.5 | vloerbedekking 1 L gelegd | milestone | 0w | 2005-05-26 | 2005-05-26 | 41d | start no earlier than 2005-05-26 |
| 35 | 6 | **AFBOUW RECHTERVLEUGEL** |  | 54d | 2005-04-20 | 2005-07-05 | 13d |  |
| 36 | 6.1 | **inbouwfase** |  | 27d | 2005-04-20 | 2005-05-27 | 40d |  |
| 37 | 6.1.1 | dekvloer 4 R gelegd | milestone | 0w | 2005-04-20 | 2005-04-20 | 67d | start no earlier than 2005-04-20 |
| 38 | 6.1.2 | dekvloer 2 R gelegd | milestone | 0w | 2005-05-06 | 2005-05-06 | 55d | start no earlier than 2005-05-06 |
| 39 | 6.1.3 | dekvloer BG R gelegd | milestone | 0w | 2005-05-23 | 2005-05-23 | 44d | start no earlier than 2005-05-23 |
| 40 | 6.1.4 | wanden 3 R gesloten | milestone | 0w | 2005-05-13 | 2005-05-13 | 50d | start no earlier than 2005-05-13 |
| 41 | 6.1.5 | wanden 1 R gesloten | milestone | 0w | 2005-05-27 | 2005-05-27 | 40d | start no earlier than 2005-05-27 |
| 42 | 6.2 | **afwerkingsfase** |  | 32d | 2005-05-20 | 2005-07-05 | 13d |  |
| 43 | 6.2.1 | plafond 4 R gesloten | milestone | 0w | 2005-05-20 | 2005-05-20 | 45d | start no earlier than 2005-05-20 |
| 44 | 6.2.2 | plafond 2 R gesloten | milestone | 0w | 2005-06-07 | 2005-06-07 | 33d | start no earlier than 2005-06-07 |
| 45 | 6.2.3 | plafond BG R gesloteb | milestone | 0w | 2005-06-22 | 2005-06-22 | 22d | start no earlier than 2005-06-22 |
| 46 | 6.2.4 | vloerbedekking 3 R gelegd | milestone | 0w | 2005-06-21 | 2005-06-21 | 23d | start no earlier than 2005-06-21 |
| 47 | 6.2.5 | vloerbedekking 1 R gelegd | milestone | 0w | 2005-07-05 | 2005-07-05 | 13d | start no earlier than 2005-07-05 |
| 48 | 7 | **OPLEVERINGS FASE** |  | 20d | 2005-06-21 | 2005-07-19 | 3d |  |
| 49 | 7.1 | bouw+instal laag 4 gekeurd | milestone | 0w | 2005-06-21 | 2005-06-21 | 23d | start no earlier than 2005-06-21 |
| 50 | 7.2 | bouw+instal laag 3 gekeurd | milestone | 0w | 2005-06-28 | 2005-06-28 | 18d | start no earlier than 2005-06-28 |
| 51 | 7.3 | bouw+instal laag 2 gekeurd | milestone | 0w | 2005-07-05 | 2005-07-05 | 13d | start no earlier than 2005-07-05 |
| 52 | 7.4 | bouw+instal laag 1 gekeurd | milestone | 0w | 2005-07-12 | 2005-07-12 | 8d | start no earlier than 2005-07-12 |
| 53 | 7.5 | bouw+instal beg.grond gekeurd | milestone | 0w | 2005-07-19 | 2005-07-19 | 3d | start no earlier than 2005-07-19 |
| 54 | 8 | GEBOUW OPGELEVERD | milestone | 0w | 2005-07-22 | 2005-07-22 | 0d | start no earlier than 2005-07-22 |
